# LCGT Plan Silica RSE Change Suspensions

Schedule from MS Project, 2012-04-01 to 2019-10-14.

## Calendars

- 働き詰め: Mon-Fri 08:00-12:00, 13:00-17:00; Sat-Sun 09:00-17:00.

## Resources

| Resource |
| --- |
| 8 |

## Schedule

| ID | WBS | Task | Type | Duration | Start | Finish | Predecessors | Total slack | Free slack | Constraint |
| --- | --- | --- | --- | --- | --- | --- | --- | --- | --- | --- |
| 1 | 1 | **Common Tasks** |  | 1461d | 2012-04-01 | 2016-03-31 |  | 0d |  |  |
| 2 | 1.1 | Excavation | manual | 730.12d | 2012-04-01 | 2014-03-31 |  |  |  |  |
| 3 | 1.2 | **Sapphire Mirror** |  | 1086d | 2013-04-11 | 2016-03-31 |  | 0d |  |  |
| 4 | 1.2.1 | ETM | manual | 24mo | 2013-04-11 | 2015-03-31 |  |  |  |  |
| 5 | 1.2.2 | ITM | manual | 24mo | 2014-04-12 | 2016-03-31 |  |  |  |  |
| 6 | 1.3 | **Vacuum Installation** |  | 365d | 2014-04-01 | 2015-03-31 |  |  |  |  |
| 7 | 1.3.1 | MC | manual | 1mo | 2014-04-01 | 2014-04-30 |  |  |  |  |
| 8 | 1.3.2 | ETMXA | manual | 1mo | 2014-04-01 | 2014-04-30 |  |  |  |  |
| 9 | 1.3.3 | ETMXB | manual | 1mo | 2014-04-01 | 2014-04-30 |  |  |  |  |
| 10 | 1.3.4 | ITMXA | manual | 1mo | 2014-09-01 | 2014-09-30 |  |  |  |  |
| 11 | 1.3.5 | ITMXB | manual | 1mo | 2014-09-01 | 2014-09-30 |  |  |  | start no earlier than 2014-09-01 |
| 12 | 1.3.6 | Central Part | manual | 1mo | 2014-09-01 | 2014-09-30 |  |  |  |  |
| 13 | 1.3.7 | ITMYA | manual | 1mo | 2014-09-01 | 2014-09-30 |  |  |  |  |
| 14 | 1.3.8 | ITMYB | manual | 1mo | 2014-09-01 | 2014-09-30 |  |  |  | start no earlier than 2014-09-01 |
| 15 | 1.3.9 | ETMYA | manual | 1mo | 2015-03-01 | 2015-03-30 |  |  |  |  |
| 16 | 1.3.10 | ETMYB | manual | 1mo | 2015-03-01 | 2015-03-30 |  |  |  | start no earlier than 2015-03-01 |
| 17 | 1.4 | **Cryostat** |  | 454d | 2014-04-01 | 2015-06-28 |  | 164d |  |  |
| 18 | 1.4.1 | Cryostat Install ETMX |  | 1mo | 2014-04-01 | 2014-04-30 | 8SS | 453d | 0d |  |
| 19 | 1.4.2 | Cryostat Test ETMX |  | 2mo | 2014-05-31 | 2014-07-29 | 18, 27 | 453d | 304d |  |
| 20 | 1.4.3 | Cryostat Install ITMX |  | 1mo | 2014-09-01 | 2014-09-30 | 10SS | 120d | 0d |  |
| 21 | 1.4.4 | Cryostat Test ITMX |  | 2mo | 2014-10-31 | 2014-12-29 | 20, 29 | 120d | 60d |  |
| 22 | 1.4.5 | Cryostat Install ITMY |  | 1mo | 2014-10-01 | 2014-10-30 | 13SS, 20 | 180d | 0d |  |
| 23 | 1.4.6 | Cryostat Test ITMY |  | 2mo | 2014-11-30 | 2015-01-28 | 22, 32 | 180d | 120d |  |
| 24 | 1.4.7 | Cryostat Install ETMY |  | 1mo | 2015-03-01 | 2015-03-30 | 15SS | 164d | 0d |  |
| 25 | 1.4.8 | Cryostat Test ETMY |  | 2mo | 2015-04-30 | 2015-06-28 | 24, 34 | 164d | 0d |  |

| ID | WBS | Task | Duration | Start | Finish | Predecessors | Total slack | Free slack |
| --- | --- | --- | --- | --- | --- | --- | --- | --- |
| 26 | 1.5 | **Clean Rooms** | 364d | 2014-05-01 | 2015-04-29 |  | 153d |  |
| 27 | 1.5.1 | ETMXA | 1mo | 2014-05-01 | 2014-05-30 | 8, 18 | 453d | 0d |
| 28 | 1.5.2 | ETMXB | 1mo | 2014-05-01 | 2014-05-30 | 9 | 483d | 0d |
| 29 | 1.5.3 | ITMXA | 1mo | 2014-10-01 | 2014-10-30 | 10, 20 | 120d | 0d |
| 30 | 1.5.4 | ITMXB | 1mo | 2014-10-01 | 2014-10-30 | 11 | 150d | 0d |
| 31 | 1.5.5 | Central Part | 1mo | 2014-10-01 | 2014-10-30 | 12 | 0d |  |
| 32 | 1.5.6 | ITMYA | 1mo | 2014-10-31 | 2014-11-29 | 13, 22 | 180d | 0d |
| 33 | 1.5.7 | ITMYB | 1mo | 2014-10-01 | 2014-10-30 | 14 | 240d | 0d |
| 34 | 1.5.8 | ETMYA | 1mo | 2015-03-31 | 2015-04-29 | 15, 24 | 164d | 0d |
| 35 | 1.5.9 | ETMYB | 1mo | 2015-03-31 | 2015-04-29 | 16 | 119d | 0d |
| 37 | 2 | **(1) Plan Silica-RSE, Aux: StackB->TypeB, TM: StackB->TypeA** | 1933d | 2014-05-01 | 2019-08-15 |  | 60d |  |
| 38 | 2.1 | **iLCGT** | 829d | 2014-05-01 | 2016-08-06 |  | 164d |  |
| 39 | 2.1.1 | MC Suspension | 1mo | 2014-05-01 | 2014-05-30 | 7 | 273d | 0d |
| 40 | 2.1.2 | **Suspension Installation for iLCGT** | 364d | 2014-05-31 | 2015-05-29 |  | 149d | 0d |
| 41 | 2.1.2.1 | ETMX (StackB) | 1mo | 2014-05-31 | 2014-06-29 | 28 | 483d |  |
| 42 | 2.1.2.2 | ITMX (StackB) | 1mo | 2014-10-31 | 2014-11-29 | 30 | 150d | 90d |
| 43 | 2.1.2.3 | PRC, BS (StackB) | 4mo | 2014-10-31 | 2015-02-27 | 31 | 60d | 0d |
| 44 | 2.1.2.4 | ITMY (StackB) | 1mo | 2014-10-31 | 2014-11-29 | 33 | 240d | 180d |
| 45 | 2.1.2.5 | ETMY (StackB) | 1mo | 2015-04-30 | 2015-05-29 | 35 | 119d | 59d |
| 46 | 2.1.3 | **Type A Commissioning** | 435d | 2015-05-30 | 2016-08-06 | 40 | 149d |  |
| 47 | 2.1.3.1 | Type A Installation ETMX | 1.5mo | 2015-05-30 | 2015-07-13 | 19 | 149d | 0d |
| 48 | 2.1.3.2 | Cryogenic Payload Test ETMX | 6mo | 2015-07-14 | 2016-01-09 | 19, 47, 4 | 194d | 0d |
| 49 | 2.1.3.3 | TypeA+CryoPayload Test ETMX | 6mo | 2016-01-10 | 2016-07-07 | 48 | 194d | 44d |
| 50 | 2.1.3.4 | Type A Installation ETMY | 1.5mo | 2015-06-29 | 2015-08-12 | 25 | 164d | 0d |
| 51 | 2.1.3.5 | Type A Test ETMY | 6mo | 2015-08-13 | 2016-02-08 | 50 | 164d | 0d |
| 52 | 2.1.3.6 | CryoPayload Install and Test ETMY | 6mo | 2016-02-09 | 2016-08-06 | 51 | 164d | 14d |
| 53 | 2.1.3.7 | ITM SAS Install and Adjust | 6mo | 2015-11-26 | 2016-05-23 | 54 | 239d | 89d |
| 54 | 2.1.4 | SRC SAS Installation | 4.5mo | 2015-07-14 | 2015-11-25 | 47 | 149d | 0d |

| ID | WBS | Task | Duration | Start | Finish | Predecessors | Total slack | Free slack |
| --- | --- | --- | --- | --- | --- | --- | --- | --- |
| 55 | 2.1.5 | **iLCGT IFO Commissioning** | 543d | 2014-05-31 | 2015-11-24 |  | 60d |  |
| 56 | 2.1.5.1 | MC Lock | 2mo | 2014-05-31 | 2014-07-29 | 39 | 273d | 213d |
| 57 | 2.1.5.2 | X-arm | 3mo | 2015-02-28 | 2015-05-28 | 43, 56, 21, 42 | 60d | 0d |
| 58 | 2.1.5.3 | Michelson | 2mo | 2015-05-29 | 2015-07-27 | 57, 44, 23 | 60d | 0d |
| 59 | 2.1.5.4 | Y-arm | 2mo | 2015-07-28 | 2015-09-25 | 58, 45 | 60d | 0d |
| 60 | 2.1.5.5 | FPMI | 2mo | 2015-09-26 | 2015-11-24 | 59 | 60d | 0d |
| 61 | 2.1.6 | iLCGT Observation | 1mo | 2015-11-25 | 2015-12-24 | 60 | 60d | 0d |
| 62 | 2.2 | **bLCGT** | 1330d | 2015-12-25 | 2019-08-15 |  | 60d |  |
| 63 | 2.2.1 | **Silica RSE** | 240d | 2015-12-25 | 2016-08-20 |  | 60d |  |
| 64 | 2.2.1.1 | PRMI | 2mo | 2015-12-25 | 2016-02-22 | 61 | 60d | 0d |
| 65 | 2.2.1.2 | DRMI | 2mo | 2016-02-23 | 2016-04-22 | 64, 54 | 60d | 0d |
| 66 | 2.2.1.3 | Silica RSE | 4mo | 2016-04-23 | 2016-08-20 | 65 | 60d | 0d |
| 67 | 2.2.2 | **Change Suspensions** | 180d | 2016-08-21 | 2017-02-16 |  | 60d | 0d |
| 68 | 2.2.2.1 | ETM | 3mo | 2016-08-21 | 2016-11-18 | 66, 49, 51, 4, 52 | 150d |  |
| 69 | 2.2.2.2 | ITM | 3mo | 2016-08-21 | 2016-11-18 | 66, 49FS-1mo, 5, 53 | 150d |  |
| 70 | 2.2.2.3 | Aux. Mirrors | 6mo | 2016-08-21 | 2017-02-16 | 66 | 60d |  |
| 71 | 2.2.3 | **Room Temp. RSE** | 180d | 2017-02-17 | 2017-08-15 | 67 | 60d | 0d |
| 72 | 2.2.3.1 | PRMI | 1mo | 2017-02-17 | 2017-03-18 |  | 60d | 0d |
| 73 | 2.2.3.2 | DRMI | 1mo | 2017-03-19 | 2017-04-17 | 72 | 60d | 0d |
| 74 | 2.2.3.3 | RSE | 4mo | 2017-04-18 | 2017-08-15 | 73 | 60d |  |
| 75 | 2.2.4 | Cryogenic RSE | 365d | 2017-08-16 | 2018-08-15 | 71 | 60d | 0d |
| 76 | 2.2.5 | Observation | 365d | 2018-08-16 | 2019-08-15 | 75 | 60d |  |
| 78 | 3 | **(2) Plan Silica-RSE, Aux: StackB, TM: StackB->TypeA** | 1843d | 2014-05-01 | 2019-05-17 |  | 150d |  |
| 79 | 3.1 | **iLCGT** | 829d | 2014-05-01 | 2016-08-06 |  | 164d |  |
| 80 | 3.1.1 | MC Suspension | 1mo | 2014-05-01 | 2014-05-30 | 7 | 363d | 0d |

| ID | WBS | Task | Duration | Start | Finish | Predecessors | Total slack | Free slack |
| --- | --- | --- | --- | --- | --- | --- | --- | --- |
| 81 | 3.1.2 | **Suspension Installation for iLCGT** | 364d | 2014-05-31 | 2015-05-29 |  | 194d | 0d |
| 82 | 3.1.2.1 | ETMX (StackB) | 1mo | 2014-05-31 | 2014-06-29 | 28 | 528d |  |
| 83 | 3.1.2.2 | ITMX (StackB) | 1mo | 2014-10-31 | 2014-11-29 | 30 | 240d | 90d |
| 84 | 3.1.2.3 | PRC, BS (StackB) | 4mo | 2014-10-31 | 2015-02-27 | 31 | 150d | 0d |
| 85 | 3.1.2.4 | ITMY (StackB) | 1mo | 2014-10-31 | 2014-11-29 | 33 | 330d | 180d |
| 86 | 3.1.2.5 | ETMY (StackB) | 1mo | 2015-04-30 | 2015-05-29 | 35 | 194d | 59d |
| 87 | 3.1.3 | **Type A Commissioning** | 435d | 2015-05-30 | 2016-08-06 | 81 | 164d |  |
| 88 | 3.1.3.1 | Type A Installation ETMX | 1.5mo | 2015-05-30 | 2015-07-13 | 19 | 194d | 0d |
| 89 | 3.1.3.2 | Cryogenic Payload Test ETMX | 6mo | 2015-07-14 | 2016-01-09 | 88 | 194d | 0d |
| 90 | 3.1.3.3 | TypeA+CryoPayload Test ETMX | 6mo | 2016-01-10 | 2016-07-07 | 89 | 194d | 44d |
| 91 | 3.1.3.4 | Type A Installation ETMY | 1.5mo | 2015-06-29 | 2015-08-12 | 25 | 164d | 0d |
| 92 | 3.1.3.5 | Type A Test ETMY | 6mo | 2015-08-13 | 2016-02-08 | 91 | 164d | 0d |
| 93 | 3.1.3.6 | CryoPayload Install and Test ETMY | 6mo | 2016-02-09 | 2016-08-06 | 92 | 164d | 14d |
| 94 | 3.1.3.7 | ITM SAS Install and Adjust | 6mo | 2015-11-26 | 2016-05-23 | 95 | 239d | 89d |
| 95 | 3.1.4 | SRC SAS Installation | 4.5mo | 2015-07-14 | 2015-11-25 | 88 | 239d | 0d |
| 96 | 3.1.5 | **iLCGT IFO Commissioning** | 543d | 2014-05-31 | 2015-11-24 |  | 150d |  |
| 97 | 3.1.5.1 | MC Lock | 2mo | 2014-05-31 | 2014-07-29 | 80 | 363d | 213d |
| 98 | 3.1.5.2 | X-arm | 3mo | 2015-02-28 | 2015-05-28 | 83, 84, 97 | 150d | 0d |
| 99 | 3.1.5.3 | Michelson | 2mo | 2015-05-29 | 2015-07-27 | 85, 98 | 150d | 0d |
| 100 | 3.1.5.4 | Y-arm | 2mo | 2015-07-28 | 2015-09-25 | 86, 99 | 150d | 0d |
| 101 | 3.1.5.5 | FPMI | 2mo | 2015-09-26 | 2015-11-24 | 100 | 150d | 0d |
| 102 | 3.1.6 | iLCGT Observation | 1mo | 2015-11-25 | 2015-12-24 | 101 | 150d | 0d |
| 103 | 3.2 | **bLCGT** | 1240d | 2015-12-25 | 2019-05-17 |  | 150d |  |
| 104 | 3.2.1 | **Silica RSE** | 240d | 2015-12-25 | 2016-08-20 |  | 150d |  |
| 105 | 3.2.1.1 | PRMI | 2mo | 2015-12-25 | 2016-02-22 | 102 | 150d | 0d |
| 106 | 3.2.1.2 | DRMI | 2mo | 2016-02-23 | 2016-04-22 | 95, 105 | 150d | 0d |
| 107 | 3.2.1.3 | Silica RSE | 4mo | 2016-04-23 | 2016-08-20 | 106 | 150d | 0d |

| ID | WBS | Task | Duration | Start | Finish | Predecessors | Total slack | Free slack |
| --- | --- | --- | --- | --- | --- | --- | --- | --- |
| 108 | 3.2.2 | **Change Suspensions** | 90d | 2016-08-21 | 2016-11-18 |  | 150d | 0d |
| 109 | 3.2.2.1 | ETM | 3mo | 2016-08-21 | 2016-11-18 | 90, 92, 107, 93 | 150d |  |
| 110 | 3.2.2.2 | ITM | 3mo | 2016-08-21 | 2016-11-18 | 90FS-1mo, 107, 94 | 150d |  |
| 111 | 3.2.2.3 | Aux. Mirrors | 2mo | 2016-08-21 | 2016-10-19 | 107 | 180d |  |
| 112 | 3.2.3 | **Room Temp. RSE** | 180d | 2016-11-19 | 2017-05-17 | 108 | 150d | 0d |
| 113 | 3.2.3.1 | PRMI | 1mo | 2016-11-19 | 2016-12-18 |  | 150d | 0d |
| 114 | 3.2.3.2 | DRMI | 1mo | 2016-12-19 | 2017-01-17 | 113 | 150d | 0d |
| 115 | 3.2.3.3 | RSE | 4mo | 2017-01-18 | 2017-05-17 | 114 | 150d |  |
| 116 | 3.2.4 | Cryogenic RSE | 365d | 2017-05-18 | 2018-05-17 | 112 | 150d | 0d |
| 117 | 3.2.5 | Observation | 365d | 2018-05-18 | 2019-05-17 | 116 | 150d |  |
| 119 | 4 | **(4) Plan Silica-RSE, Aux: TypeB, TM: StackB->TypeA** | 1933d | 2014-05-01 | 2019-08-15 |  | 60d |  |
| 120 | 4.1 | **iLCGT** | 829d | 2014-05-01 | 2016-08-06 |  | 164d |  |
| 121 | 4.1.1 | MC Suspension | 1mo | 2014-05-01 | 2014-05-30 | 7 | 363d | 0d |
| 122 | 4.1.2 | **Suspension Installation for iLCGT** | 364d | 2014-05-31 | 2015-05-29 |  | 164d | 0d |
| 123 | 4.1.2.1 | ETMX (StackB) | 1mo | 2014-05-31 | 2014-06-29 | 28 | 498d |  |
| 124 | 4.1.2.2 | ITMX (StackB) | 1mo | 2014-10-31 | 2014-11-29 | 30 | 240d | 180d |
| 125 | 4.1.2.3 | PRC, BS (TypeB) | 7mo | 2014-10-31 | 2015-05-28 | 31 | 60d | 0d |
| 126 | 4.1.2.4 | ITMY (StackB) | 1mo | 2014-10-31 | 2014-11-29 | 33 | 330d | 270d |
| 127 | 4.1.2.5 | ETMY (StackB) | 1mo | 2015-04-30 | 2015-05-29 | 35 | 164d | 149d |
| 128 | 4.1.3 | **Type A Commissioning** | 435d | 2015-05-30 | 2016-08-06 | 122 | 164d |  |
| 129 | 4.1.3.1 | Type A Installation ETMX | 1.5mo | 2015-05-30 | 2015-07-13 | 19 | 164d | 0d |
| 130 | 4.1.3.2 | Cryogenic Payload Test ETMX | 6mo | 2015-07-14 | 2016-01-09 | 129 | 194d | 0d |
| 131 | 4.1.3.3 | TypeA+CryoPayload Test ETMX | 6mo | 2016-01-10 | 2016-07-07 | 130 | 194d | 134d |
| 132 | 4.1.3.4 | Type A Installation ETMY | 1.5mo | 2015-06-29 | 2015-08-12 | 25 | 164d | 0d |
| 133 | 4.1.3.5 | Type A Test ETMY | 6mo | 2015-08-13 | 2016-02-08 | 132 | 164d | 0d |
| 134 | 4.1.3.6 | CryoPayload Install and Test ETMY | 6mo | 2016-02-09 | 2016-08-06 | 133 | 164d | 104d |
| 135 | 4.1.3.7 | ITM SAS Install and Adjust | 6mo | 2016-02-09 | 2016-08-06 | 136 | 164d | 104d |
| 136 | 4.1.4 | SRC SAS Installation | 7mo | 2015-07-14 | 2016-02-08 | 129 | 164d | 0d |

| ID | WBS | Task | Duration | Start | Finish | Predecessors | Total slack | Free slack |
| --- | --- | --- | --- | --- | --- | --- | --- | --- |
| 137 | 4.1.5 | **iLCGT IFO Commissioning** | 633d | 2014-05-31 | 2016-02-22 |  | 60d |  |
| 138 | 4.1.5.1 | MC Lock | 2mo | 2014-05-31 | 2014-07-29 | 121 | 363d | 303d |
| 139 | 4.1.5.2 | X-arm | 3mo | 2015-05-29 | 2015-08-26 | 124, 125, 138 | 60d | 0d |
| 140 | 4.1.5.3 | Michelson | 2mo | 2015-08-27 | 2015-10-25 | 126, 139 | 60d | 0d |
| 141 | 4.1.5.4 | Y-arm | 2mo | 2015-10-26 | 2015-12-24 | 127, 140 | 60d | 0d |
| 142 | 4.1.5.5 | FPMI | 2mo | 2015-12-25 | 2016-02-22 | 141 | 60d | 0d |
| 143 | 4.1.6 | iLCGT Observation | 1mo | 2016-02-23 | 2016-03-23 | 142 | 60d | 0d |
| 144 | 4.2 | **bLCGT** | 1240d | 2016-03-24 | 2019-08-15 |  | 60d |  |
| 145 | 4.2.1 | **Silica RSE** | 240d | 2016-03-24 | 2016-11-18 |  | 60d |  |
| 146 | 4.2.1.1 | PRMI | 2mo | 2016-03-24 | 2016-05-22 | 143 | 60d | 0d |
| 147 | 4.2.1.2 | DRMI | 2mo | 2016-05-23 | 2016-07-21 | 136, 146 | 60d | 0d |
| 148 | 4.2.1.3 | Silica RSE | 4mo | 2016-07-22 | 2016-11-18 | 147 | 60d | 0d |
| 149 | 4.2.2 | **Change Suspensions** | 90d | 2016-11-19 | 2017-02-16 |  | 60d | 0d |
| 150 | 4.2.2.1 | ETM | 3mo | 2016-11-19 | 2017-02-16 | 131, 133, 148, 134 | 60d |  |
| 151 | 4.2.2.2 | ITM | 3mo | 2016-11-19 | 2017-02-16 | 131FS-1mo, 148, 135 | 60d |  |
| 152 | 4.2.2.3 | Aux. Mirrors | 2mo | 2016-11-19 | 2017-01-17 | 148 | 90d |  |
| 153 | 4.2.3 | **Room Temp. RSE** | 180d | 2017-02-17 | 2017-08-15 | 149 | 60d | 0d |
| 154 | 4.2.3.1 | PRMI | 1mo | 2017-02-17 | 2017-03-18 |  | 60d | 0d |
| 155 | 4.2.3.2 | DRMI | 1mo | 2017-03-19 | 2017-04-17 | 154 | 60d | 0d |
| 156 | 4.2.3.3 | RSE | 4mo | 2017-04-18 | 2017-08-15 | 155 | 60d |  |
| 157 | 4.2.4 | Cryogenic RSE | 365d | 2017-08-16 | 2018-08-15 | 153 | 60d | 0d |
| 158 | 4.2.5 | Observation | 365d | 2018-08-16 | 2019-08-15 | 157 | 60d |  |
| 160 | 5 | **(6) Plan No-Silica-RSE, Aux: StackB->TypeB, TM: StackB->TypeA** | 1829d | 2014-05-01 | 2019-05-03 |  | 164d |  |
| 161 | 5.1 | **iLCGT** | 829d | 2014-05-01 | 2016-08-06 |  | 423d |  |
| 162 | 5.1.1 | MC Suspension | 1mo | 2014-05-01 | 2014-05-30 | 7 | 453d | 0d |

| ID | WBS | Task | Duration | Start | Finish | Predecessors | Total slack | Free slack | Constraint |
| --- | --- | --- | --- | --- | --- | --- | --- | --- | --- |
| 163 | 5.1.2 | **Suspension Installation for iLCGT** | 364d | 2014-05-31 | 2015-05-29 |  | 164d | 0d |  |
| 164 | 5.1.2.1 | ETMX (StackB) | 1mo | 2014-05-31 | 2014-06-29 | 28 | 498d |  |  |
| 165 | 5.1.2.2 | ITMX (StackB) | 1mo | 2014-10-31 | 2014-11-29 | 30 | 330d | 90d |  |
| 166 | 5.1.2.3 | PRC, BS (StackB) | 4mo | 2014-10-31 | 2015-02-27 | 31 | 240d | 0d |  |
| 167 | 5.1.2.4 | ITMY (StackB) | 1mo | 2014-10-31 | 2014-11-29 | 33 | 345d | 180d |  |
| 168 | 5.1.2.5 | ETMY (StackB) | 1mo | 2015-04-30 | 2015-05-29 | 35 | 164d | 59d |  |
| 169 | 5.1.3 | **Type A Commissioning** | 435d | 2015-05-30 | 2016-08-06 | 163 | 164d |  |  |
| 170 | 5.1.3.1 | Type A Installation ETMX | 1.5mo | 2015-05-30 | 2015-07-13 | 19 | 164d | 0d |  |
| 171 | 5.1.3.2 | Cryogenic Payload Test ETMX | 6mo | 2015-07-14 | 2016-01-09 | 170 | 164d | 0d |  |
| 172 | 5.1.3.3 | TypeA+CryoPayload Test ETMX | 6mo | 2016-01-10 | 2016-07-07 | 171 | 164d | 0d |  |
| 173 | 5.1.3.4 | Type A Installation ETMY | 1.5mo | 2015-06-29 | 2015-08-12 | 25 | 1134d | 0d |  |
| 174 | 5.1.3.5 | Type A Test ETMY | 6mo | 2015-08-13 | 2016-02-08 | 173 | 1134d | 0d |  |
| 175 | 5.1.3.6 | CryoPayload Install and Test ETMY | 6mo | 2016-02-09 | 2016-08-06 | 174 | 1134d | 0d |  |
| 176 | 5.1.3.7 | ITM SAS Install and Adjust | 6mo | 2015-07-14 | 2016-01-09 | 170 | 314d | 0d |  |
| 177 | 5.1.4 | SRC SAS Installation | 4.5mo | 2016-01-10 | 2016-05-23 | 176 | 329d | 165d |  |
| 178 | 5.1.5 | **iLCGT IFO Commissioning** | 543d | 2014-05-31 | 2015-11-24 |  | 240d |  |  |
| 179 | 5.1.5.1 | MC Lock | 2mo | 2014-05-31 | 2014-07-29 | 162 | 453d | 213d |  |
| 180 | 5.1.5.2 | X-arm | 3mo | 2015-02-28 | 2015-05-28 | 165, 166, 179, 21 | 240d | 0d |  |
| 181 | 5.1.5.3 | Michelson | 2mo | 2015-05-29 | 2015-07-27 | 167, 180, 23 | 240d | 0d |  |
| 182 | 5.1.5.4 | Y-arm | 2mo | 2015-07-28 | 2015-09-25 | 168, 181 | 240d | 0d |  |
| 183 | 5.1.5.5 | FPMI | 2mo | 2015-09-26 | 2015-11-24 | 182 | 240d | 0d |  |
| 184 | 5.1.6 | iLCGT Observation | 1mo | 2015-11-25 | 2015-12-24 | 183 | 240d | 0d |  |
| 185 | 5.2 | **bLCGT** | 1226d | 2015-12-25 | 2019-05-03 |  | 164d |  |  |
| 186 | 5.2.1 | **Change Suspensions** | 256d | 2015-12-25 | 2016-09-05 | 184 | 240d |  |  |
| 187 | 5.2.1.1 | ETM | 1mo | 2016-08-07 | 2016-09-05 | 172, 174, 4, 175 | 1134d |  | start no earlier than 2014-09-01 |
| 188 | 5.2.1.2 | ITM | 3mo | 2016-06-08 | 2016-09-05 | 172FS-1mo, 5, 176 | 164d | 0d |  |
| 189 | 5.2.1.3 | Aux. Mirrors | 6mo | 2015-12-25 | 2016-06-21 |  | 240d | 76d |  |

| ID | WBS | Task | Duration | Start | Finish | Predecessors | Total slack | Free slack |
| --- | --- | --- | --- | --- | --- | --- | --- | --- |
| 190 | 5.2.2 | **Room Temp. RSE** | 240d | 2016-09-06 | 2017-05-03 |  | 164d | 0d |
| 191 | 5.2.2.1 | PRMI | 2mo | 2016-09-06 | 2016-11-04 | 189, 188 | 164d | 0d |
| 192 | 5.2.2.2 | DRMI | 2mo | 2016-11-05 | 2017-01-03 | 177, 191 | 164d | 0d |
| 193 | 5.2.2.3 | RSE | 4mo | 2017-01-04 | 2017-05-03 | 192 | 164d |  |
| 194 | 5.2.3 | Cryogenic RSE | 365d | 2017-05-04 | 2018-05-03 | 190 | 164d | 0d |
| 195 | 5.2.4 | Observation | 365d | 2018-05-04 | 2019-05-03 | 194 | 164d |  |
| 197 | 6 | **(7) Plan No-Silica-RSE, Aux.:StackB, TM: StackB->TypeA** | 1829d | 2014-05-01 | 2019-05-03 |  | 164d |  |
| 198 | 6.1 | **iLCGT** | 829d | 2014-05-01 | 2016-08-06 |  | 438d |  |
| 199 | 6.1.1 | MC Suspension | 1mo | 2014-05-01 | 2014-05-30 | 7 | 543d | 0d |
| 200 | 6.1.2 | **Suspension Installation for iLCGT** | 364d | 2014-05-31 | 2015-05-29 |  | 164d | 0d |
| 201 | 6.1.2.1 | ETMX (StackB) | 1mo | 2014-05-31 | 2014-06-29 | 28 | 498d |  |
| 202 | 6.1.2.2 | ITMX (StackB) | 1mo | 2014-10-31 | 2014-11-29 | 30 | 345d | 90d |
| 203 | 6.1.2.3 | PRC, BS (StackB) | 4mo | 2014-10-31 | 2015-02-27 | 31 | 255d | 0d |
| 204 | 6.1.2.4 | ITMY (StackB) | 1mo | 2014-10-31 | 2014-11-29 | 33 | 345d | 180d |
| 205 | 6.1.2.5 | ETMY (StackB) | 1mo | 2015-04-30 | 2015-05-29 | 35 | 164d | 59d |
| 206 | 6.1.3 | **Type A Commissioning** | 435d | 2015-05-30 | 2016-08-06 | 200 | 164d |  |
| 207 | 6.1.3.1 | Type A Installation ETMX | 1.5mo | 2015-05-30 | 2015-07-13 | 19 | 164d | 0d |
| 208 | 6.1.3.2 | Cryogenic Payload Test ETMX | 6mo | 2015-07-14 | 2016-01-09 | 207 | 164d | 0d |
| 209 | 6.1.3.3 | TypeA+CryoPayload Test ETMX | 6mo | 2016-01-10 | 2016-07-07 | 208 | 164d | 0d |
| 210 | 6.1.3.4 | Type A Installation ETMY | 1.5mo | 2015-06-29 | 2015-08-12 | 25 | 1134d | 0d |
| 211 | 6.1.3.5 | Type A Test ETMY | 6mo | 2015-08-13 | 2016-02-08 | 210 | 1134d | 0d |
| 212 | 6.1.3.6 | CryoPayload Install and Test ETMY | 6mo | 2016-02-09 | 2016-08-06 | 211 | 1134d | 0d |
| 213 | 6.1.3.7 | ITM SAS Install and Adjust | 6mo | 2015-07-14 | 2016-01-09 | 207 | 314d | 0d |
| 214 | 6.1.4 | SRC SAS Installation | 4.5mo | 2016-01-10 | 2016-05-23 | 213 | 329d | 165d |

Notes:
- 197: Silica RSEなし / Aux. MirrorはStackBのまま。 / TMはStackBからTypeAへ途中で変更 / (6)との変更点は、Change SuspensionにおけるAux. Mirrorにかかる / 期間が2ヶ月と短縮されたこと。2ヶ月かかるのは、PRC/SRCのモード / マッチングのために、位置の変更をする必要があるから。

| ID | WBS | Task | Duration | Start | Finish | Predecessors | Total slack | Free slack | Constraint |
| --- | --- | --- | --- | --- | --- | --- | --- | --- | --- |
| 215 | 6.1.5 | **iLCGT IFO Commissioning** | 543d | 2014-05-31 | 2015-11-24 |  | 330d |  |  |
| 216 | 6.1.5.1 | MC Lock | 2mo | 2014-05-31 | 2014-07-29 | 199 | 543d | 213d |  |
| 217 | 6.1.5.2 | X-arm | 3mo | 2015-02-28 | 2015-05-28 | 202, 203, 216 | 330d | 0d |  |
| 218 | 6.1.5.3 | Michelson | 2mo | 2015-05-29 | 2015-07-27 | 204, 217 | 330d | 0d |  |
| 219 | 6.1.5.4 | Y-arm | 2mo | 2015-07-28 | 2015-09-25 | 205, 218 | 330d | 0d |  |
| 220 | 6.1.5.5 | FPMI | 2mo | 2015-09-26 | 2015-11-24 | 219 | 330d | 0d |  |
| 221 | 6.1.6 | iLCGT Observation | 1mo | 2015-11-25 | 2015-12-24 | 220 | 330d | 0d |  |
| 222 | 6.2 | **bLCGT** | 1226d | 2015-12-25 | 2019-05-03 |  | 164d |  |  |
| 223 | 6.2.1 | **Change Suspensions** | 256d | 2015-12-25 | 2016-09-05 | 221 | 330d |  |  |
| 224 | 6.2.1.1 | ETM | 1mo | 2016-08-07 | 2016-09-05 | 209, 211, 212 | 1134d |  | start no earlier than 2014-09-01 |
| 225 | 6.2.1.2 | ITM | 3mo | 2016-06-08 | 2016-09-05 | 209FS-1mo, 213 | 164d | 0d |  |
| 226 | 6.2.1.3 | Aux. Mirrors Tweaks | 2mo | 2015-12-25 | 2016-02-22 |  | 360d | 196d |  |
| 227 | 6.2.2 | **Room Temp. RSE** | 240d | 2016-09-06 | 2017-05-03 |  | 164d | 0d |  |
| 228 | 6.2.2.1 | PRMI | 2mo | 2016-09-06 | 2016-11-04 | 225, 226 | 164d | 0d |  |
| 229 | 6.2.2.2 | DRMI | 2mo | 2016-11-05 | 2017-01-03 | 214, 228 | 164d | 0d |  |
| 230 | 6.2.2.3 | RSE | 4mo | 2017-01-04 | 2017-05-03 | 229 | 164d |  |  |
| 231 | 6.2.3 | Cryogenic RSE | 365d | 2017-05-04 | 2018-05-03 | 227 | 164d | 0d |  |
| 232 | 6.2.4 | Observation | 365d | 2018-05-04 | 2019-05-03 | 231 | 164d |  |  |
| 234 | 7 | **(9) Plan No-Silica-RSE, Aux: TypeB, TM: StackB -> TypeA** | 1829d | 2014-05-01 | 2019-05-03 |  | 164d |  |  |
| 235 | 7.1 | **iLCGT** | 829d | 2014-05-01 | 2016-08-06 |  | 348d |  |  |
| 236 | 7.1.1 | MC Suspension | 1mo | 2014-05-01 | 2014-05-30 | 7 | 543d | 0d |  |
| 237 | 7.1.2 | **Suspension Installation for iLCGT** | 364d | 2014-05-31 | 2015-05-29 |  | 164d | 0d |  |
| 238 | 7.1.2.1 | ETMX (StackB) | 1mo | 2014-05-31 | 2014-06-29 | 28 | 498d |  |  |
| 239 | 7.1.2.2 | ITMX (StackB) | 1mo | 2014-10-31 | 2014-11-29 | 30 | 345d | 180d |  |
| 240 | 7.1.2.3 | PRC, BS (TypeB) | 7mo | 2014-10-31 | 2015-05-28 | 31 | 165d | 0d |  |
| 241 | 7.1.2.4 | ITMY (StackB) | 1mo | 2014-10-31 | 2014-11-29 | 33 | 345d | 270d |  |
| 242 | 7.1.2.5 | ETMY (StackB) | 1mo | 2015-04-30 | 2015-05-29 | 35 | 164d | 149d |  |

Notes:
- 234: Silica RSEなし / Aux. Mirrorは最初からTypeB。 / TMはStackBからTypeAへ途中で変更 / (6)との変更点は、 / (a) Suspension Installation for iLCGTにおける、PRC, BSの作業 / 期間が7ヶ月になっている。 / (b) SRC Suspensionの設置期間が7ヶ月/ (c) Change SuspensionにおけるAux. Mirrorにかかる / 期間が2ヶ月と短縮された。2ヶ月かかるのは、PRC/SRCのモード / マッチングのために、位置の変更をする必要があるから。

| ID | WBS | Task | Duration | Start | Finish | Predecessors | Total slack | Free slack | Constraint |
| --- | --- | --- | --- | --- | --- | --- | --- | --- | --- |
| 243 | 7.1.3 | **Type A Commissioning** | 435d | 2015-05-30 | 2016-08-06 | 237 | 164d |  |  |
| 244 | 7.1.3.1 | Type A Installation ETMX | 1.5mo | 2015-05-30 | 2015-07-13 | 19 | 164d | 0d |  |
| 245 | 7.1.3.2 | Cryogenic Payload Test ETMX | 6mo | 2015-07-14 | 2016-01-09 | 244 | 164d | 0d |  |
| 246 | 7.1.3.3 | TypeA+CryoPayload Test ETMX | 6mo | 2016-01-10 | 2016-07-07 | 245 | 164d | 0d |  |
| 247 | 7.1.3.4 | Type A Installation ETMY | 1.5mo | 2015-06-29 | 2015-08-12 | 25 | 1134d | 0d |  |
| 248 | 7.1.3.5 | Type A Test ETMY | 6mo | 2015-08-13 | 2016-02-08 | 247 | 1134d | 0d |  |
| 249 | 7.1.3.6 | CryoPayload Install and Test ETMY | 6mo | 2016-02-09 | 2016-08-06 | 248 | 1134d | 0d |  |
| 250 | 7.1.3.7 | ITM SAS Install and Adjust | 6mo | 2015-07-14 | 2016-01-09 | 244 | 254d | 0d |  |
| 251 | 7.1.4 | SRC SAS Installation | 7mo | 2016-01-10 | 2016-08-06 | 250 | 254d | 90d |  |
| 252 | 7.1.5 | **iLCGT IFO Commissioning** | 633d | 2014-05-31 | 2016-02-22 |  | 240d |  |  |
| 253 | 7.1.5.1 | MC Lock | 2mo | 2014-05-31 | 2014-07-29 | 236 | 543d | 303d |  |
| 254 | 7.1.5.2 | X-arm | 3mo | 2015-05-29 | 2015-08-26 | 239, 240, 253 | 240d | 0d | start no earlier than 2015-02-28 |
| 255 | 7.1.5.3 | Michelson | 2mo | 2015-08-27 | 2015-10-25 | 241, 254 | 240d | 0d |  |
| 256 | 7.1.5.4 | Y-arm | 2mo | 2015-10-26 | 2015-12-24 | 242, 255 | 240d | 0d |  |
| 257 | 7.1.5.5 | FPMI | 2mo | 2015-12-25 | 2016-02-22 | 256 | 240d | 0d |  |
| 258 | 7.1.6 | iLCGT Observation | 1mo | 2016-02-23 | 2016-03-23 | 257 | 240d | 0d |  |
| 259 | 7.2 | **bLCGT** | 1136d | 2016-03-24 | 2019-05-03 |  | 164d |  |  |
| 260 | 7.2.1 | **Change Suspensions** | 166d | 2016-03-24 | 2016-09-05 | 258 | 240d |  |  |
| 261 | 7.2.1.1 | ETM | 1mo | 2016-08-07 | 2016-09-05 | 246, 248, 249 | 1134d |  | start no earlier than 2014-09-01 |
| 262 | 7.2.1.2 | ITM | 3mo | 2016-06-08 | 2016-09-05 | 246FS-1mo, 250 | 164d | 0d |  |
| 263 | 7.2.1.3 | Aux. Mirrors | 2mo | 2016-03-24 | 2016-05-22 |  | 270d | 106d |  |
| 264 | 7.2.2 | **Room Temp. RSE** | 240d | 2016-09-06 | 2017-05-03 |  | 164d | 0d |  |
| 265 | 7.2.2.1 | PRMI | 2mo | 2016-09-06 | 2016-11-04 | 262, 263 | 164d | 0d |  |
| 266 | 7.2.2.2 | DRMI | 2mo | 2016-11-05 | 2017-01-03 | 251, 265 | 164d | 0d |  |
| 267 | 7.2.2.3 | RSE | 4mo | 2017-01-04 | 2017-05-03 | 266 | 164d |  |  |
| 268 | 7.2.3 | Cryogenic RSE | 365d | 2017-05-04 | 2018-05-03 | 264 | 164d | 0d |  |
| 269 | 7.2.4 | Observation | 365d | 2018-05-04 | 2019-05-03 | 268 | 164d |  |  |

| ID | WBS | Task | Duration | Start | Finish | Predecessors | Total slack | Free slack | Constraint |
| --- | --- | --- | --- | --- | --- | --- | --- | --- | --- |
| 271 | 8 | **(10) Plan No-Silica-RSE, Aux: TypeB, TM: TypeA** | 1993d | 2014-05-01 | 2019-10-14 |  | 0d |  |  |
| 272 | 8.1 | **iLCGT** | 753d | 2014-05-01 | 2016-05-22 |  | 183d |  |  |
| 273 | 8.1.1 | MC Suspension | 1mo | 2014-05-01 | 2014-05-30 | 7 | 363d | 0d |  |
| 274 | 8.1.2 | **Suspension Installation for iLCGT** | 423d | 2014-05-31 | 2015-07-27 |  | 153d | 0d |  |
| 275 | 8.1.2.1 | ETMX (TypeA) | 2mo | 2014-05-31 | 2014-07-29 | 28 | 783d |  |  |
| 276 | 8.1.2.2 | ITMX (TypeA) | 2mo | 2014-10-31 | 2014-12-29 | 30 | 210d |  |  |
| 277 | 8.1.2.3 | PRC, BS (TypeB) | 9mo | 2014-10-31 | 2015-07-27 | 31 | 0d |  |  |
| 278 | 8.1.2.4 | ITMY (TypeA) | 2mo | 2014-10-31 | 2014-12-29 | 33 | 300d |  |  |
| 279 | 8.1.2.5 | ETMY (TypeA) | 2mo | 2015-04-30 | 2015-06-28 | 35 | 179d |  |  |
| 280 | 8.1.3 | SRC SAS Installation | 7mo | 2015-07-28 | 2016-02-22 | 274 | 420d | 210d |  |
| 281 | 8.1.4 | **iLCGT IFO Commissioning** | 693d | 2014-05-31 | 2016-04-22 |  | 0d |  |  |
| 282 | 8.1.4.1 | MC Lock | 2mo | 2014-05-31 | 2014-07-29 | 273 | 363d |  |  |
| 283 | 8.1.4.2 | X-arm | 3mo | 2015-07-28 | 2015-10-25 | 276, 277, 282 | 0d |  | start no earlier than 2015-02-28 |
| 284 | 8.1.4.3 | Michelson | 2mo | 2015-10-26 | 2015-12-24 | 278, 283 | 0d |  |  |
| 285 | 8.1.4.4 | Y-arm | 2mo | 2015-12-25 | 2016-02-22 | 279, 284 | 0d |  |  |
| 286 | 8.1.4.5 | FPMI | 2mo | 2016-02-23 | 2016-04-22 | 285 | 0d |  |  |
| 287 | 8.1.5 | iLCGT Observation | 1mo | 2016-04-23 | 2016-05-22 | 286 | 0d |  |  |
| 288 | 8.2 | **bLCGT** | 1240d | 2016-05-23 | 2019-10-14 |  | 0d |  |  |
| 289 | 8.2.1 | **CryoPayload Test** | 360d | 2016-06-22 | 2017-06-16 | 287 | 0d |  |  |
| 290 | 8.2.1.1 | Cryogenic Payload Test ETM | 6mo | 2016-06-22 | 2016-12-18 | 294 | 0d |  |  |
| 291 | 8.2.1.2 | TypeA+CryoPayload Test ETM | 6mo | 2016-12-19 | 2017-06-16 | 290 | 0d |  |  |
| 292 | 8.2.2 | **Change Suspensions** | 60d | 2016-05-23 | 2016-07-21 | 287 | 0d |  |  |
| 293 | 8.2.2.1 | ITM (Change Mirrors) | 1mo | 2016-05-23 | 2016-06-21 |  | 240d | 30d |  |
| 294 | 8.2.2.2 | ETM (Change Mirrors) | 1mo | 2016-05-23 | 2016-06-21 |  | 0d |  |  |
| 295 | 8.2.2.3 | Aux. Mirrors Tweaks | 2mo | 2016-05-23 | 2016-07-21 |  | 210d | 0d |  |

Notes:
- 271: Silica RSEなし / Aux. Mirrorは最初からTypeB。 / TMも最初からTypeA / iLCGT用サスペンションのインストール期間は14ヶ月 / TypeAにもSilicaミラーが吊られる

| ID | WBS | Task | Duration | Start | Finish | Predecessors | Total slack | Free slack |
| --- | --- | --- | --- | --- | --- | --- | --- | --- |
| 296 | 8.2.3 | **Room Temp. RSE** | 450d | 2016-07-22 | 2017-10-14 |  | 0d |  |
| 297 | 8.2.3.1 | PRMI | 2mo | 2016-07-22 | 2016-09-19 | 295, 293 | 210d | 0d |
| 298 | 8.2.3.2 | DRMI | 2mo | 2016-09-20 | 2016-11-18 | 280, 297 | 210d |  |
| 299 | 8.2.3.3 | RSE | 4mo | 2017-06-17 | 2017-10-14 | 298, 289 | 0d |  |
| 300 | 8.2.4 | Cryogenic RSE | 365d | 2017-10-15 | 2018-10-14 | 296 | 0d |  |
| 301 | 8.2.5 | Observation | 365d | 2018-10-15 | 2019-10-14 | 300 | 0d |  |
